# wgo revamp

How a schedule from Planner changed from version to version. A marks actual dates.

## Version 1 (saved 2024-05-18)

| ID | WBS | Task | Duration | Start | Finish | Predecessors | Complete | Constraint |
| --- | --- | --- | --- | --- | --- | --- | --- | --- |
| 1 |  | 2.16 release | 0d | 2006-09-06 | 2006-09-06 |  |  | must start on 2006-09-06 |
| 2 |  | 2.16.1 release | 0d | 2006-10-04 | 2006-10-04 |  |  | must start on 2006-10-04 |
| 3 | 3 | **Policies** |  | 2006-08-18 | 2006-08-22 |  |  |  |
| 4 |  | Policies Draft |  | 2006-08-18 | 2006-08-20 |  | 100% |  |
| 5 |  | Policies Revision |  | 2006-08-20 | 2006-08-22 | 4 | 100% |  |
| 6 | 4 | **Core planning** |  | 2006-08-18 | 2006-08-30 |  |  |  |
| 7 | 4.1 | **Scope** |  | 2006-08-18 | 2006-08-24 |  |  |  |
| 8 |  | Scope Draft |  | 2006-08-18 | 2006-08-20 |  | 100% |  |
| 9 |  | Scope Revision |  | 2006-08-20 | 2006-08-22 | 8 | 100% |  |
| 10 |  | *go Partitioning draft |  | 2006-08-20 | 2006-08-22 | 8 | 100% |  |
| 11 |  | *go Partitioning revision |  | 2006-08-22 | 2006-08-24 | 10 |  |  |
| 12 | 4.2 | **Use cases** |  | 2006-08-18 | 2006-08-23 |  |  |  |
| 13 |  | Use Draft |  | 2006-08-18 | 2006-08-21 |  | 100% |  |
| 14 |  | Use Revision |  | 2006-08-21 | 2006-08-23 | 13 | 50% |  |
| 15 | 4.3 | **Site structure** |  | 2006-08-21 | 2006-08-27 | 8, 13 | 75% |  |
| 16 |  | Site draft |  | 2006-08-21 | 2006-08-25 |  | 50% |  |
| 17 |  | Site Revision |  | 2006-08-25 | 2006-08-27 | 16 |  |  |
| 18 | 4.4 | **Navigation** |  | 2006-08-25 | 2006-08-30 | 16 |  |  |
| 19 |  | Nav. Draft |  | 2006-08-25 | 2006-08-28 |  | 50% |  |
| 20 |  | Nav. Revision |  | 2006-08-28 | 2006-08-30 | 19 |  |  |
| 21 | 5 | **Layout planning** |  | 2006-08-18 | 2006-09-02 |  |  |  |
| 22 | 5.1 | **Page components** |  | 2006-08-18 | 2006-08-30 |  |  |  |
| 23 |  | Page components draft |  | 2006-08-18 | 2006-08-22 |  | 100% |  |
| 24 |  | Page components revision |  | 2006-08-23 | 2006-08-26 | 14 |  |  |
| 25 |  | Home components draft |  | 2006-08-20 | 2006-08-22 | 23SS+48h | 100% |  |
| 26 |  | Home components revision |  | 2006-08-27 | 2006-08-30 | 17, 25 |  |  |
| 27 | 5.2 | **Page structure** |  | 2006-08-22 | 2006-09-02 |  |  |  |
| 28 |  | Pagestr. draft |  | 2006-08-22 | 2006-08-25 | 25 |  |  |
| 29 |  | Pagestr. revision |  | 2006-08-26 | 2006-08-29 | 24 |  |  |
| 30 |  | Homestr. draft |  | 2006-08-27 | 2006-08-30 | 28FS+48h, 25 |  |  |
| 31 |  | Homestr. revision |  | 2006-08-30 | 2006-09-02 | 30, 26 |  |  |
| 32 | 6 | **Look&Feel** |  | 2006-09-06 | 2006-09-22 | 1SS |  |  |
| 33 |  | L&F draft |  | 2006-09-06 | 2006-09-15 |  |  |  |
| 34 |  | L&F tuning |  | 2006-09-15 | 2006-09-22 | 33 |  |  |
| 35 | 7 | **CMS selection** |  | 2006-09-06 | 2006-09-30 |  |  |  |
| 36 |  | 1st round draft |  | 2006-09-06 | 2006-09-14 | 42SS | 10% |  |
| 37 |  | 1st round revision |  | 2006-09-14 | 2006-09-16 | 36 |  |  |
| 38 |  | final round draft |  | 2006-09-16 | 2006-09-26 | 33, 43, 37 |  |  |
| 39 |  | final round revision |  | 2006-09-26 | 2006-09-30 | 38 |  |  |
| 40 |  | Develop test themes |  | 2006-09-19 | 2006-09-24 | 31, 29, 38SS+72h, 33 |  |  |
| 41 | 8 | **i18n requirements** |  | 2006-09-06 | 2006-09-15 | 1SS |  |  |
| 42 |  | Minimal and optimal reqs draft |  | 2006-09-06 | 2006-09-12 |  | 25% |  |
| 43 |  | Minimal and optimal reqs revision |  | 2006-09-12 | 2006-09-15 | 42 |  |  |
| 44 | 9 | **GNOME Products alpha** |  | 2006-08-18 | 2006-09-02 |  |  |  |
| 45 |  | Relation with gnomefiles.org |  | 2006-08-18 | 2006-08-18 |  | 100% |  |
| 46 |  | Reqs & workflow draft |  | 2006-08-18 | 2006-08-22 |  |  |  |
| 47 |  | Reqs & workflow revision |  | 2006-08-22 | 2006-08-24 | 46 |  |  |
| 48 |  | List of sections and products draft |  | 2006-08-22 | 2006-08-25 | 46 |  |  |
| 49 |  | List of sections and products revision |  | 2006-08-25 | 2006-08-28 | 48 |  |  |
| 50 |  | Page components draft |  | 2006-08-22 | 2006-08-25 | 46 |  |  |
| 51 |  | Page components revision |  | 2006-08-26 | 2006-08-28 | 50, 24 |  |  |
| 52 |  | Page structure draft |  | 2006-08-25 | 2006-08-28 | 50 |  |  |
| 53 |  | Pages structure revision |  | 2006-08-29 | 2006-08-31 | 52, 29 |  |  |
| 54 |  | GNOME Products alpha |  | 2006-08-26 | 2006-09-02 | 51SS, 49SS |  |  |
| 55 | 10 | **GNOME Products beta** |  | 2006-09-06 | 2006-09-30 | 54, 1SS |  |  |
| 56 |  | Alpha testing |  | 2006-09-06 | 2006-09-20 |  |  |  |
| 57 |  | Beta Look&Feel |  | 2006-09-22 | 2006-09-25 | 34 |  |  |
| 58 |  | Beta product pages |  | 2006-09-06 | 2006-09-15 |  |  |  |
| 59 |  | Beta DOAP implementation |  | 2006-09-11 | 2006-09-20 | 58SS+120h |  |  |
| 60 |  | CMS integration??? |  | 2006-09-26 | 2006-09-30 | 38 |  |  |
| 61 |  | Beta release??? |  | 2006-09-25 | 2006-09-30 | 59, 58, 57, 56 |  |  |
| 62 | 11 | **News gateway alpha** |  | 2006-08-18 | 2006-09-02 |  |  |  |
| 63 |  | News reqs and workflow draft |  | 2006-08-18 | 2006-08-20 |  |  |  |
| 64 |  | News reqs and workflow revision |  | 2006-08-20 | 2006-08-22 | 63 |  |  |
| 65 |  | News sources list draft |  | 2006-08-20 | 2006-08-23 | 63 |  |  |
| 66 |  | News sources list revision |  | 2006-08-23 | 2006-08-25 | 65 |  |  |
| 67 |  | News components draft |  | 2006-08-20 | 2006-08-23 | 63 |  |  |
| 68 |  | News components revision |  | 2006-08-26 | 2006-08-28 | 24, 67 |  |  |
| 69 |  | News structure draft |  | 2006-08-28 | 2006-08-31 | 68 |  |  |
| 70 |  | News structure revision |  | 2006-08-31 | 2006-09-02 | 29, 69 |  |  |

| ID | WBS | Task | Start | Finish | Predecessors |
| --- | --- | --- | --- | --- | --- |
| 71 |  | News gateway alpha | 2006-08-26 | 2006-09-02 | 68SS |
| 72 | 12 | **News gateway beta** | 2006-09-06 | 2006-09-29 | 62, 1SS |
| 73 |  | Alpha news testing | 2006-09-06 | 2006-09-12 |  |
| 74 |  | Beta news look&feel | 2006-09-22 | 2006-09-25 | 34 |
| 75 |  | Beta release | 2006-09-25 | 2006-09-29 | 74 |

## Version 2 (saved 2024-05-22)

Last finish 2006-10-04 → 2006-10-17 (+13d). Complete tasks 9 → 17.

Removed: 41 i18n requirements; 42 Minimal and optimal reqs draft; 43 Minimal and optimal reqs revision; 44 GNOME Products alpha; 46 Reqs & workflow draft; 47 Reqs & workflow revision; 48 List of sections and products draft; 49 List of sections and products revision; 50 Page components draft; 51 Page components revision; 52 Page structure draft; 53 Pages structure revision; 54 GNOME Products alpha; 55 GNOME Products beta; 56 Alpha testing; 57 Beta Look&Feel; 58 Beta product pages; 59 Beta DOAP implementation; 60 CMS integration???; 61 Beta release???; 62 News gateway alpha; 63 News reqs and workflow draft; 64 News reqs and workflow revision; 65 News sources list draft; 66 News sources list revision; 67 News components draft; 68 News components revision; 69 News structure draft; 70 News structure revision; 71 News gateway alpha; 72 News gateway beta; 73 Alpha news testing; 74 Beta news look&feel; 75 Beta release

Changed:

| ID | Task | Start | Finish | Complete | Predecessors | Other |
| --- | --- | --- | --- | --- | --- | --- |
| 6 | **Core planning** |  | 2006-08-30 → 2006-09-17 (+18d) |  |  |  |
| 11 | *go Partitioning revision |  |  | 0% → 100% |  |  |
| 14 | Use Revision |  |  | 50% → 100% |  |  |
| 15 | **Site structure** |  | 2006-08-27 → 2006-09-15 (+19d) |  |  |  |
| 16 | Site draft |  |  | 50% → 100% |  |  |
| 17 | Site Revision | 2006-08-25 → 2006-09-09 (+15d) | 2006-08-27 → 2006-09-15 (+19d) | 0% → 75% |  | constraint none → must start on 2006-09-09 |
| 18 | **Navigation** | 2006-08-25 → 2006-09-09 (+15d) | 2006-08-30 → 2006-09-17 (+18d) |  |  |  |
| 19 | Nav. Draft | 2006-08-25 → 2006-09-09 (+15d) | 2006-08-28 → 2006-09-11 (+14d) | 50% → 100% |  | constraint none → must start on 2006-09-09 |
| 20 | Nav. Revision | 2006-08-28 → 2006-09-15 (+18d) | 2006-08-30 → 2006-09-17 (+18d) |  | 19 → 15, 19 |  |
| 21 | **Layout planning** |  | 2006-09-02 → 2006-09-24 (+22d) |  |  |  |
| 22 | **Page components** |  | 2006-08-30 → 2006-09-18 (+19d) |  |  |  |
| 24 | Page components revision |  |  | 0% → 100% |  |  |
| 26 | Home components revision | 2006-08-27 → 2006-09-15 (+19d) | 2006-08-30 → 2006-09-18 (+19d) | 0% → 100% |  |  |
| 27 | **Page structure** |  | 2006-09-02 → 2006-09-24 (+22d) |  |  |  |
| 28 | Pagestr. draft | 2006-08-22 → 2006-09-08 (+17d) | 2006-08-25 → 2006-09-10 (+16d) | 0% → 100% |  | constraint none → must start on 2006-09-08 |
| 29 | Pagestr. revision | 2006-08-26 → 2006-09-21 (+26d) | 2006-08-29 → 2006-09-24 (+26d) |  | 24 → 31, 28, 24 |  |
| 30 | Homestr. draft | 2006-08-27 → 2006-08-22 (-5d) | 2006-08-30 → 2006-08-25 (-5d) | 0% → 100% | 28FS+48h, 25 → 25 |  |
| 31 | Homestr. revision | 2006-08-30 → 2006-09-18 (+19d) | 2006-09-02 → 2006-09-21 (+19d) | 0% → 75% |  |  |
| 32 | **Look&Feel** |  | 2006-09-22 → 2006-09-27 (+5d) |  |  |  |
| 33 | L&F draft |  | 2006-09-15 → 2006-09-20 (+5d) | 0% → 25% |  |  |
| 34 | L&F tuning | 2006-09-15 → 2006-09-20 (+5d) | 2006-09-22 → 2006-09-27 (+5d) |  |  |  |
| 35 | **CMS selection** | 2006-09-06 → 2006-09-18 (+12d) | 2006-09-30 → 2006-10-17 (+17d) |  |  |  |
| 36 | 1st round draft | 2006-09-06 → 2006-09-18 (+12d) | 2006-09-14 → 2006-09-27 (+13d) |  | Minimal and optimal reqs draftSS → none | constraint none → must start on 2006-09-18 |
| 37 | 1st round revision | 2006-09-14 → 2006-09-27 (+13d) | 2006-09-16 → 2006-10-02 (+16d) |  |  |  |
| 38 | final round draft | 2006-09-16 → 2006-10-02 (+16d) | 2006-09-26 → 2006-10-12 (+16d) |  | 33, Minimal and optimal reqs revision, 37 → 33, 37 |  |
| 39 | final round revision | 2006-09-26 → 2006-10-12 (+16d) | 2006-09-30 → 2006-10-17 (+17d) |  |  |  |
| 40 | Develop test themes | 2006-09-19 → 2006-09-27 (+8d) | 2006-09-24 → 2006-10-07 (+13d) |  | 31, 29, 38SS+72h, 33 → 36, 31, 29, 33 |  |
